# frictiontestsched_070207

Schedule from MS Project, 2007-06-29 to 2007-09-27.
pppl

## Calendars

- Standard: Mon-Fri 08:00-12:00, 13:00-17:00; Sat-Sun off.

## Resources

| Resource |
| --- |
| D. Williiamson |
| G. Gettelfiniger |
| G. Gettelfiniger/Jurz. |

## Schedule

| ID | WBS | Task | Duration | Start | Finish | Predecessors | Total slack | Free slack | Constraint | Resources | Work |
| --- | --- | --- | --- | --- | --- | --- | --- | --- | --- | --- | --- |
| 2 | 1 | 1st friction life test 9500 psi, mu=0.4, 130,000 cycles | 5d? | 2007-07-02 | 2007-07-06 |  | 55d | 0d | finish no earlier than 2007-07-06 | G. Gettelfiniger/Jurz. | 40h |
| 3 | 2 | mu=0.5 130,000 | 2d | 2007-07-09 | 2007-07-10 | 2 | 55d | 0d |  | G. Gettelfiniger/Jurz. | 16h |
| 4 | 3 | mu=0.6, 130,000 cycles | 2d | 2007-07-11 | 2007-07-12 | 3 | 55d |  |  | G. Gettelfiniger/Jurz. | 16h |
| 5 | 4 | Procure test 2-4 specimens | 21d | 2007-07-02 | 2007-07-30 |  | 2d | 0d | start no earlier than 2007-07-02 | G. Gettelfiniger/Jurz. | 168h |
| 6 | 5 | 2nd friction life test 9500 psi, mu=0.4, 130,000 cycles | 3d | 2007-07-31 | 2007-08-02 | 5 | 2d | 0d |  | G. Gettelfiniger/Jurz. | 24h |
| 7 | 6 | 3rd friction life test 9500 psi mu=0.4, 130,000 cycles | 3d | 2007-08-03 | 2007-08-07 | 6 | 2d | 0d |  | G. Gettelfiniger/Jurz. | 24h |
| 8 | 7 | 4th friction life test 9500 psi mu=0.4 130,000 cycles | 3d | 2007-08-08 | 2007-08-10 | 7 | 2d | 0d |  | G. Gettelfiniger/Jurz. | 24h |
| 9 | 8 | write report | 3d | 2007-08-13 | 2007-08-15 | 8 | 31d |  |  | G. Gettelfiniger/Jurz. | 24h |
| 11 | 9 | Specify bolt test hardware | 3d | 2007-06-29 | 2007-07-03 |  | 0d |  |  | D. Williiamson | 24h |
| 12 | 10 | Select shim style | 2d | 2007-07-04 | 2007-07-05 | 11 | 0d |  |  | D. Williiamson | 16h |
| 13 | 11 | In-house machininig of hardware | 7d | 2007-07-06 | 2007-07-16 | 12 | 0d |  |  | G. Gettelfiniger/Jurz. | 56h |
| 14 | 12 | alumina coating at supplier | 21d | 2007-07-17 | 2007-08-14 | 13 | 0d |  |  | G. Gettelfiniger/Jurz. | 168h |
| 15 | 13 | Test 1: Perform Superbolt torque-load tests | 1d? | 2007-06-29 | 2007-06-29 |  | 64d |  |  | G. Gettelfiniger/Jurz. | 8h |
| 16 | 14 | Test 2: Confirm accuracy of new UT tester at RT | 2d | 2007-08-15 | 2007-08-16 | 8, 14 | 0d |  |  | G. Gettelfiniger/Jurz. | 16h |
| 17 | 15 | Test 2A: Confirm accuracy of new UT tester at 80K. | 3d | 2007-08-17 | 2007-08-21 | 16 | 0d |  |  | G. Gettelfiniger/Jurz. | 24h |
| 18 | 16 | Test 3A: Determine preload deflection test for Thru-Thru config. | 2d | 2007-08-22 | 2007-08-23 | 17 | 0d |  |  | G. Gettelfiniger/Jurz. | 16h |
| 19 | 17 | Test 3B: Same as 3A but at 80K | 2d | 2007-08-24 | 2007-08-27 | 18 | 0d |  |  | G. Gettelfiniger/Jurz. | 16h |
| 20 | 18 | Test 3C: Same as 3A, but Thru-Tapped | 2d | 2007-08-28 | 2007-08-29 | 19 | 0d |  |  | G. Gettelfiniger/Jurz. | 16h |
| 21 | 19 | Test3D: Same as 3C but at 80K: | 2d | 2007-08-30 | 2007-08-31 | 20 | 0d |  |  | G. Gettelfiniger/Jurz. | 16h |
| 22 | 20 | Test 4: Det. Change iln preload due to(6) RT-80K cycles Thru-Thru | 6d | 2007-09-03 | 2007-09-10 | 21 | 0d |  |  | G. Gettelfiniger/Jurz. | 48h |
| 23 | 21 | Test 4A: As above, but Thru-Tapped | 6d | 2007-09-11 | 2007-09-18 | 22 | 0d |  |  | G. Gettelfiniger/Jurz. | 48h |
| 24 | 22 | Write report | 7d | 2007-09-19 | 2007-09-27 | 23 | 0d |  |  |  |  |

Notes:
- 2: This test will be made with specimens on hand. Wil use bond coated specimen.
- 5: Specimens to be made wlith bond coat alumina 0.026" thick. / use the side plate specimens / will get 4 pair made.
- 11: Possible configurations: / 2 flanges wlith thru holes / 1 thru, 1 tapped / Need to know configuration, washer details, etc. This is probably just the drawing package shown Friday. (Dave).
- 12: In general, specify details of the test hardware. / Should we use shims which are available now or make per the latest drawings? / If we use the available shims, the holes need to be bored to the new diameter.
- 14: Bonded coating; 0.026" thick.
