# frictiontestsched_070907

Schedule from MS Project, 2007-06-29 to 2007-08-24.
pppl

## Calendars

- Standard: Mon-Fri 08:00-12:00, 13:00-17:00; Sat-Sun off.

## Resources

| Resource |
| --- |
| D. Williiamson |
| G. Gettelfiniger |
| G. Gettelfiniger/Jurz. |

## Schedule

| ID | WBS | Task | Duration | Start | Finish | Predecessors | Total slack | Free slack | Constraint | Resources | Work |
| --- | --- | --- | --- | --- | --- | --- | --- | --- | --- | --- | --- |
| 2 | 1 | 1st friction life test 9500 psi, mu=0.4, 130,000 cycles | 5d? | 2007-07-02 | 2007-07-06 |  | 55d | 0d | finish no earlier than 2007-07-06 | G. Gettelfiniger/Jurz. | 40h |
| 3 | 2 | mu=0.5 130,000 | 2d | 2007-07-09 | 2007-07-10 | 2 | 55d | 0d |  | G. Gettelfiniger/Jurz. | 16h |
| 4 | 3 | mu=0.6, 130,000 cycles | 2d | 2007-07-11 | 2007-07-12 | 3 | 55d |  |  | G. Gettelfiniger/Jurz. | 16h |
| 5 | 4 | Procure test 2-4 specimens, old style shim w/1.5" holes | 21d | 2007-07-02 | 2007-07-30 |  | 7d | 0d | start no earlier than 2007-07-02 | G. Gettelfiniger/Jurz. | 168h |
| 6 | 5 | 2nd friction life test 9500 psi, mu=0.4, 130,000 cycles | 3d | 2007-07-31 | 2007-08-02 | 5 | 2d | 0d |  | G. Gettelfiniger/Jurz. | 24h |
| 7 | 6 | 3rd friction life test 9500 psi mu=0.4, 130,000 cycles | 3d | 2007-08-03 | 2007-08-07 | 6 | 2d | 0d |  | G. Gettelfiniger/Jurz. | 24h |
| 8 | 7 | 4th friction life test 9500 psi mu=0.4 130,000 cycles | 3d | 2007-08-08 | 2007-08-10 | 7 | 2d | 0d |  | G. Gettelfiniger/Jurz. | 24h |
| 9 | 8 | write report | 3d | 2007-08-13 | 2007-08-15 | 8 | 31d |  |  | G. Gettelfiniger/Jurz. | 24h |
| 11 | 9 | Specify bolt test hardware -i.e., bolt kit drawing.of 7/10. | 3d | 2007-06-29 | 2007-07-03 |  | 6d | 0d |  | D. Williiamson | 24h |
| 12 | 10 | Select shim style - use existing shim for testsed w/bored 1.5 hole. | 2d | 2007-07-04 | 2007-07-05 | 11 | 6d | 0d |  | D. Williiamson | 16h |
| 13 | 11 | In-house machining of hardware - G10/11, Inco. Washers (similar but not exact to kit). | 7d | 2007-07-06 | 2007-07-16 | 12 | 6d | 0d |  | G. Gettelfiniger/Jurz. | 56h |
| 14 | 12 | alumina coating at supplier - 0.5 shim coated 0.026/side alumina; approx. 14 pcs. | 21d | 2007-07-17 | 2007-08-14 | 13 | 6d | 0d |  | G. Gettelfiniger/Jurz. | 168h |
| 15 | 13 | Perform edge loading shim tests | 1d? | 2007-07-25 | 2007-07-25 |  | 22d |  | start no earlier than 2007-07-25 |  |  |
| 16 | 13 | Test 1: Perform Superbolt torque-load tests | 1d? | 2007-06-29 | 2007-06-29 |  | 40d |  |  | G. Gettelfiniger/Jurz. | 8h |
| 17 | 14 | Test 2: Confirm accuracy of new UT tester at RT | 2d | 2007-08-15 | 2007-08-16 | 8, 14 | 6d |  |  | G. Gettelfiniger/Jurz. | 16h |
| 18 | 16 | Contact LBL and MicroMeasurements re: resistive magnet applications. | 6d? | 2007-07-11 | 2007-07-18 |  | 0d |  | finish no earlier than 2007-07-18 |  |  |
| 19 | 18 | Test 3A: Same as 3A, but Thru-Tapped | 2d | 2007-07-19 | 2007-07-20 | 18 | 0d |  |  | G. Gettelfiniger/Jurz. | 16h |
| 20 | 19 | Test3B: Same as 3C but at 80K: (cool down article fr. 3C) | 2d | 2007-07-23 | 2007-07-24 | 19 | 0d |  |  | G. Gettelfiniger/Jurz. | 16h |
| 21 | 16 | Test 3A: Determine preload deflection test for Thru-Thru config. (bolt stretch & fl-fl delta) | 2d | 2007-07-25 | 2007-07-26 | 20 | 0d |  |  | G. Gettelfiniger/Jurz. | 16h |
| 22 | 17 | Test 3B: Same as 3A but at 80K (cool down article fr. 3A) | 2d | 2007-07-27 | 2007-07-30 | 21 | 0d |  |  | G. Gettelfiniger/Jurz. | 16h |
| 23 | 20 | Test 4: Det. Change in preload due to (10) RT-80K cycles Thru-Thru | 6d | 2007-07-31 | 2007-08-07 | 22 | 0d |  |  | G. Gettelfiniger/Jurz. | 48h |
| 24 | 21 | Test 4A: As above, but Thru-Tapped | 6d | 2007-08-08 | 2007-08-15 | 23 | 0d |  |  | G. Gettelfiniger/Jurz. | 48h |
| 25 | 22 | Write report | 7d | 2007-08-16 | 2007-08-24 | 24 | 0d |  |  |  |  |
| 28 | 24 | ORNL bolt tests:(already outlined on Ron's schedule) | 1d? | 2007-06-29 | 2007-06-29 |  | 40d |  |  |  |  |
| 29 | 25 | Test ability of FO gauge bolts to monitor preload & load. | 1d? | 2007-06-29 | 2007-06-29 |  | 40d |  |  |  |  |
| 30 | 26 | Produce & coat full scale shims for tests below. | 1d? | 2007-07-26 | 2007-07-26 | 15 | 21d |  |  |  |  |
| 31 | 27 | Perform FO bolt test at RT | 1d? | 2007-06-29 | 2007-06-29 |  | 40d |  |  |  |  |
| 32 | 28 | Perform bolt / shim shear test at RT | 1d? | 2007-06-29 | 2007-06-29 |  | 40d |  |  |  |  |
| 33 | 29 | validate that shims will perform to spec with representative joint | 1d? | 2007-06-29 | 2007-06-29 |  | 40d |  |  |  |  |
| 34 | 30 | determine change in preload as temp. goes to 80K and cycled mechanically | 1d? | 2007-06-29 | 2007-06-29 |  | 40d |  |  |  |  |
| 35 | 31 | validate FEA models - ie, at 80K & reduced preload,have shim slip to load up bolt/bushing to measure stiffness of bolt/bushing load path. | 1d? | 2007-06-29 | 2007-06-29 |  | 40d |  |  |  |  |
| 36 | 32 | Repeat (34), but without bushings to determine contribution of bushings to load path stiffness.(OPTIONAL) | 1d? | 2007-06-29 | 2007-06-29 |  | 40d |  |  |  |  |
| 37 | 33 | Repeat Task 34 at 80K. | 1d? | 2007-06-29 | 2007-06-29 |  | 40d |  |  |  |  |
| 38 | 34 | Mechanical cycling tests - ramp to 25 kips to 0 repeatedly.(like 6-8, but with full scale shims) 130K/4 cycles | 1d? | 2007-06-29 | 2007-06-29 |  | 40d |  |  |  |  |
| 40 | 35 | FDR for bolted interface late July; all of the above is confirmatory - needs to be done prior to first field period assy. | 1d? | 2007-06-29 | 2007-06-29 |  | 40d |  |  |  |  |

Notes:
- 2: This test will be made with specimens on hand. Wil use bond coated specimen.
- 5: Specimens to be made wlith bond coat alumina 0.026" thick. / use the side plate specimens / will get 4 pair made.
- 11: Possible configurations: / 2 flanges wlith thru holes / 1 thru, 1 tapped / Need to know configuration, washer details, etc. This is probably just the drawing package shown Friday. (Dave).
- 12: In general, specify details of the test hardware. / Should we use shims which are available now or make per the latest drawings? / If we use the available shims, the holes need to be bored to the new diameter.
- 14: Bonded coating; 0.026" thick.
